# SISPBO Patents & SPC

Schedule from MS Project, 2021-04-19 to 2024-09-05, status date 2022-09-27, A marks actual dates.

## Calendars

- Standard: Mon-Fri 08:00-12:00, 13:00-17:00; Sat-Sun off. Exceptions (off unless hours are given): 2022-04-30 to 2022-05-15 (Matjaz's Holidays), 2023-12-23 to 2024-01-02 08:00-12:00, 13:00-17:00 (FGL holidays).

## Resources

| Resource |
| --- |
| EUIPO |
| SIPO |
| EUIPO BA |
| EUIPO QA |
| SIPO DEV |
| SIPO, EUIPO |
| SIPO, EUIPO BA |
| SIPO, EUIPO |
| SIPO |
| SIPO PM |
| SIPO PM, DPM |
| SIPO PM, DPM, EUIPO |
| SIPO PM, SIPO KBU, EUIPO BA |
| SIPO TL, EUIPO TL, EUIPO IA |
| SIPO TL, EUIPO TL |
| SIPO TL, SIPO DEVm EUIPO TL |
| SIPO TL, SIPO DEV, EUIPO TL |
| SIPO TL |
| SIPO PM, SIPO KBU |
| MP |
| SIPO Exec |
| SIPO Board |
| MJ, MP |
| MJ |
| MGRT |
| SIPO, MGRT |
| MGRT, SIPO |
| MP, AD, DS |
| SIPO External Dev |
| SIPO Dev |
| SIPO External Dev, SIPO |
| SIPO External Dev, SIPO Dev |
| SIPO Dev, SIPO External Dev |
| SIPO, SIPO Dev, SIPO Ex |
| SIPO, SIPO External Dev |
| EPO |
| GOV |
| MF |

## Schedule

| ID | WBS | Task | Type | Duration | Start | Finish | Predecessors | Complete | Remaining | Baseline start | Baseline finish | Baseline duration | Baseline 1 start | Baseline 1 finish | Total slack | Free slack | Constraint | Resources | Work | Actual work | Text5 | Text11 |
| --- | --- | --- | --- | --- | --- | --- | --- | --- | --- | --- | --- | --- | --- | --- | --- | --- | --- | --- | --- | --- | --- | --- |
| 1 | 1 | **External Dependencies** |  | 636d | 2021-04-19 A | 2023-10-09 |  | 15% | 542.38d | 2021-04-19 | 2023-10-09 | 646d | 2021-01-31 | 2021-04-08 | 127d |  |  |  | 1664h | 1664h | 09/06/17 | 0% |
| 2 | 1.1 | SISPBO FGL | milestone | 0d | 2021-04-19 A | 2021-04-19 A |  | 100% |  | 2021-04-19 | 2021-04-19 | 0d | 2021-02-11 | 2021-02-11 |  |  | start no earlier than 2021-04-19 | SIPO |  |  |  |  |
| 3 | 1.2 | SISPBO v3 ready | milestone | 0w | 2022-05-16 | 2022-05-16 | 2 |  |  | 2022-05-16 | 2022-05-16 | 0w | 2021-03-05 | 2021-04-08 | 83d |  | start no earlier than 2022-05-16 | SIPO |  |  |  |  |
| 4 | 1.3 | GAP analysis completed | milestone | 0d | 2021-12-16 A | 2021-12-16 A | 2 | 100% |  | 2021-12-16 | 2021-12-16 | 0d |  |  |  |  |  | MP |  |  |  |  |
| 5 | 1.4 | MVP defined |  | 6w | 2021-12-16 A | 2022-01-26 A | 2, 4 | 100% |  | 2021-12-16 | 2022-01-26 | 6w |  |  |  |  | start no earlier than 2021-12-16 | SIPO | 240h | 240h |  |  |
| 6 | 1.5 | Setup cost prepared and aprooved |  | 52d | 2022-01-27 A | 2022-04-08 A | 5 | 100% |  | 2022-01-27 | 2022-04-08 | 52d | 2021-03-24 | 2021-03-31 |  |  | start no earlier than 2021-09-01 | MP | 416h | 416h |  |  |
| 7 | 1.6 | Funding assured | milestone | 0d | 2022-04-08 A | 2022-04-08 A | 6 | 100% |  | 2022-04-08 | 2022-04-08 | 0d |  |  |  |  | start no earlier than 2022-01-31 | SIPO Exec |  |  |  |  |
| 8 | 1.7 | Processes modeled | milestone | 0d | 2021-08-11 A | 2021-08-11 A |  | 100% |  | 2021-08-11 | 2021-08-11 | 0d |  |  |  |  | start no earlier than 2021-08-11 | SIPO; EPO |  |  |  |  |
| 9 | 1.8 | Government council approval |  | 6.2w | 2022-04-11 A | 2022-06-06 A | 6, 7 | 100% |  | 2022-04-11 | 2022-05-06 | 1mo |  |  |  |  |  | SIPO; GOV | 496h | 496h |  |  |
| 10 | 1.9 | NRP agreed |  | 6.4w | 2022-04-11 A | 2022-06-07 A | 7 | 100% |  |  |  |  |  |  |  |  |  | SIPO; MF | 512h | 512h |  |  |
| 11 | 1.10 | FO EP designation implemented |  | 10mo | 2023-01-03 | 2023-10-09 |  |  |  | 2023-01-03 | 2023-10-09 | 10mo |  |  | 110d |  | start no earlier than 2023-01-03 |  |  |  |  |  |
| 12 | 1.11 | IPUR completed |  | 16mo | 2022-07-01 | 2023-09-21 |  |  |  | 2022-07-01 | 2023-09-21 | 16mo |  |  | 110d | 95d | start no earlier than 2022-07-01 |  |  |  |  |  |
| 13 | 1.12 | CSHF completed |  | 16mo | 2022-06-01 | 2023-08-22 |  |  |  | 2022-06-01 | 2023-08-22 | 16mo |  |  | 124d | 57d | start no earlier than 2022-06-01 |  |  |  |  |  |
| 14 | 2 | **Objectives** |  | 619d | 2021-12-16 A | 2024-05-08 |  |  | 619d | 2021-12-16 | 2024-02-12 | 567d |  |  | 86d |  |  |  |  |  |  |  |
| 15 | 2.1 | Kickoff | milestone | 0d | 2021-12-16 A | 2021-12-16 A | 20 | 100% |  | 2021-12-16 | 2021-12-16 | 0d |  |  |  |  |  |  |  |  |  |  |
| 16 | 2.2 | FGL | milestone | 0d | 2024-03-28 | 2024-03-28 | 132 |  |  | 2024-01-02 | 2024-01-02 | 0d |  |  | 115d |  |  |  |  |  |  |  |
| 17 | 2.3 | FGL with management reserve | milestone | 0d | 2024-05-08 | 2024-05-08 | 133 |  |  | 2024-02-12 | 2024-02-12 | 0d |  |  | 86d |  |  |  |  |  |  |  |
| 18 | 3 | **Project Management** |  | 705d? | 2021-12-16 A | 2024-09-05 |  | 90% | 66.98d? | 2021-12-16 | 2024-06-11 | 653d? | 2021-02-11 | 2021-11-15 | 0d |  |  |  | 2768h | 2488h | 09/06/17 | 0% |
| 19 | 3.1 | **Project Initiation** |  | 82d? | 2021-12-16 A | 2022-04-08 A |  | 100% |  | 2021-12-16 | 2022-04-08 | 82d? | 2021-02-15 | 2021-03-31 |  |  |  |  | 2488h | 2488h | 09/06/17 | 0% |
| 20 | 3.1.1 | Kickoff |  | 1d | 2021-12-16 A | 2021-12-16 A | 4 | 100% |  | 2021-12-16 | 2021-12-16 | 1d |  |  |  |  |  | SIPO | 8h | 8h |  |  |
| 21 | 3.1.2 | **Project plan** |  | 33d | 2022-02-23 A | 2022-04-08 A |  | 100% |  | 2022-02-23 | 2022-04-08 | 33d |  |  |  |  |  |  | 240h | 240h |  |  |
| 22 | 3.1.2.1 | Draft detailed project plan |  | 29d | 2022-02-23 A | 2022-04-04 A | 6FF-3d | 100% |  | 2022-02-23 | 2022-04-04 | 29d |  |  |  |  |  | MP | 232h | 232h |  |  |
| 23 | 3.1.2.2 | Aproove project plan |  | 1d | 2022-04-08 A | 2022-04-08 A | 22, 6FF | 100% |  | 2022-04-08 | 2022-04-08 | 1d |  |  |  |  |  | SIPO Board | 8h | 8h |  |  |
| 24 | 3.1.3 | **Prepare Strategies** |  | 81d? | 2021-12-17 A | 2022-04-08 A |  | 100% |  | 2021-12-17 | 2022-04-08 | 81d? | 2021-02-15 | 2021-02-19 |  |  |  |  | 2240h | 2240h |  |  |
| 25 | 3.1.3.1 | Risk Management Strategy |  | 13.8w | 2021-12-17 A | 2022-03-23 A | 20 | 100% |  | 2021-12-17 | 2022-03-23 | 13.8w | 2021-02-15 | 2021-02-19 |  |  | start no earlier than 2021-08-23 | MP | 552h | 552h |  |  |
| 26 | 3.1.3.2 | Communication Strategy |  | 14.2w | 2021-12-17 A | 2022-03-25 A | 20 | 100% |  | 2021-12-17 | 2022-03-25 | 14.2w | 2021-02-15 | 2021-02-19 |  |  | start no earlier than 2021-08-23 | MP | 568h | 568h |  |  |
| 27 | 3.1.3.3 | Quality Management Strategy |  | 13.8w | 2021-12-17 A | 2022-03-23 A | 20 | 100% |  | 2021-12-17 | 2022-03-23 | 13.8w | 2021-02-15 | 2021-02-19 |  |  | start no earlier than 2021-08-23 | MP | 552h | 552h |  |  |
| 28 | 3.1.3.4 | Configuration Management Strategy (project change management) |  | 14w | 2021-12-17 A | 2022-03-24 A | 20 | 100% |  | 2021-12-17 | 2022-03-24 | 14w | 2021-02-15 | 2021-02-19 |  |  | start no earlier than 2021-08-23 | MP | 560h | 560h |  |  |
| 29 | 3.1.3.5 | Data Migration Strategy |  | 70d? | 2021-12-17 A | 2022-03-24 A |  | 100% |  | 2021-12-17 | 2022-03-24 | 70d? |  |  |  |  |  |  |  |  |  |  |
| 30 | 3.1.3.6 | Approval of strategies |  | 1d | 2022-04-08 A | 2022-04-08 A | 25, 27, 26, 28, 6FF | 100% |  | 2022-04-08 | 2022-04-08 | 1d | 2021-02-22 | 2021-02-22 |  |  |  | SIPO Board | 8h | 8h |  |  |
| 31 | 3.2 | M0.1 Initiation Completed | milestone | 0d | 2022-04-08 A | 2022-04-08 A | 23, 30 | 100% |  | 2022-04-08 | 2022-04-08 | 0d | 2021-03-31 | 2021-03-31 |  |  |  |  |  |  | 09/06/17 | 0% |

Notes:
- 12: Zgodnji začetek, ker za implementacijo migracije potrebujemo shemo in testne podakte
- 24: Status 10.07.2020 MA: All 4 strategies drafted by 3/7/20 and are in review by SIPO PM. Should be completed before contract signed and external provider starts development.

| ID | WBS | Task | Type | Duration | Start | Finish | Predecessors | Baseline start | Baseline finish | Baseline duration | Baseline 1 start | Baseline 1 finish | Total slack | Free slack | Resources | Work | Text5 | Text11 | Text25 | Text26 | Text27 | Text4 | Text6 |
| --- | --- | --- | --- | --- | --- | --- | --- | --- | --- | --- | --- | --- | --- | --- | --- | --- | --- | --- | --- | --- | --- | --- | --- |
| 32 | 3.3 | **Controlling** |  | 495d | 2022-10-20 | 2024-09-05 |  | 2022-07-07 | 2024-06-11 | 508d | 2021-02-11 | 2021-11-15 | 0d |  |  | 280h | 09/06/17 | 0% |  |  |  |  |  |
| 33 | 3.3.1 | **SIPO Interin Execution Reports** |  | 385d | 2022-10-20 | 2024-04-04 |  | 2022-07-07 | 2024-01-09 | 398d | 2021-04-15 | 2021-09-30 | 95d |  |  | 160h |  |  |  |  |  |  |  |
| 34 | 3.3.1.1 | Interim ER Nr 1 (upon analysis completed) |  | 1w | 2022-10-20 | 2022-10-26 | 101, 86, 93, 100 | 2022-07-07 | 2022-07-13 | 1w | 2021-04-15 | 2021-04-21 | 455d | 38d | MP | 40h |  |  |  |  |  |  |  |
| 35 | 3.3.1.2 | Interim ER Nr2 (upon tender completed) |  | 1w | 2022-12-20 | 2022-12-26 | 57, 34 | 2022-09-16 | 2022-09-22 | 1w |  |  | 417d | 265d |  |  |  |  |  |  |  |  |  |
| 36 | 3.3.1.3 | Interim ER Nr 3 (upon development completed) |  | 1w | 2023-12-29 | 2024-01-02 | 109, 110, 114, 35 | 2023-09-29 | 2023-10-05 | 1w | 2021-09-24 | 2021-09-30 | 152d | 41d | MP | 40h |  |  |  |  |  |  |  |
| 37 | 3.3.1.4 | Interim ER Nr 4 (upon testing completed) |  | 1w | 2024-02-29 | 2024-03-06 | 120, 124, 36 | 2023-12-04 | 2023-12-08 | 1w |  |  | 111d | 16d | MP | 40h |  |  |  |  |  |  |  |
| 38 | 3.3.1.5 | Interim ER Nr 5 (upon FGL) |  | 1w | 2024-03-29 | 2024-04-04 | 134, 37 | 2024-01-03 | 2024-01-09 | 1w |  |  | 95d |  | MP | 40h |  |  |  |  |  |  |  |
| 39 | 3.3.2 | **Project Closure** |  | 15d | 2024-08-16 | 2024-09-05 |  | 2024-05-22 | 2024-06-11 | 15d | 2021-10-26 | 2021-11-15 | 0d |  |  | 120h | 09/06/17 | 0% |  |  |  |  |  |
| 40 | 3.3.2.1 | Final Execution Report |  | 1w | 2024-08-16 | 2024-08-22 | 148, 38, 136 | 2024-05-22 | 2024-05-28 | 1w | 2021-11-09 | 2021-11-15 | 0d |  | MP | 40h | 09/06/17 | 0% |  |  |  |  |  |
| 41 | 3.3.2.2 | Project closure's documents |  | 2w | 2024-08-23 | 2024-09-05 | 148, 40 | 2024-05-29 | 2024-06-11 | 2w | 2021-10-26 | 2021-11-08 | 0d |  | SIPO | 80h | 09/06/17 | 0% |  |  |  |  |  |
| 42 | 3.4 | M0.2 Project Completed | milestone | 0d | 2024-09-05 | 2024-09-05 | 41 | 2024-06-11 | 2024-06-11 | 0d | 2021-11-15 | 2021-11-15 | 0d |  |  |  | 09/06/17 | 0% |  |  |  |  |  |
| 43 | 3.5 | D0.1 Lessons Learned | milestone | 0d | 2024-09-05 | 2024-09-05 | 41 | 2024-06-11 | 2024-06-11 | 0d | 2021-11-08 | 2021-11-08 | 0d |  |  |  | 09/06/17 | 0% |  |  |  |  |  |
| 44 | 4 | **Activation of local external provider** |  | 181d | 2022-04-08 | 2023-01-02 |  | 2022-04-08 | 2022-09-29 | 124d |  |  | 0d |  |  | 848h | Tue 7.09.21 | 100% | 2017-09-18 | 2019-07-05 | 440 |  |  |
| 45 | 4.1 | **-->Inbound dependencies** |  | 115d | 2022-04-08 | 2022-09-30 |  | 2022-04-08 | 2022-07-06 | 63d |  |  | 0d |  |  |  | Tue 7.09.21 | 100% | 2017-09-18 | 2019-02-04 | 336 |  |  |
| 46 | 4.1.1 | Analysis completed | milestone | 0d | 2022-09-30 | 2022-09-30 | 102, 103, 93, 86 | 2022-07-06 | 2022-07-06 | 0d |  |  | 0d |  |  |  | Tue 7.09.21 | 100% | 2018-09-11 | 2018-09-11 |  |  |  |
| 47 | 4.1.2 | Initiation completed | milestone | 0d | 2022-04-08 | 2022-04-08 | 31 | 2022-04-08 | 2022-04-08 | 0d |  |  | 73d |  |  |  | Tue 7.09.21 | 100% | 2018-08-31 | 2018-08-31 |  |  |  |
| 48 | 4.1.3 | Government council approval | milestone | 0d | 2022-06-06 | 2022-06-06 | 9 | 2022-05-06 | 2022-05-06 | 0d |  |  | 67d |  |  |  |  |  |  |  |  |  |  |
| 49 | 4.2 | **Tender activities** |  | 96d | 2022-08-08 | 2022-12-19 |  | 2022-05-26 | 2022-09-15 | 81d |  |  | 0d |  |  | 768h |  |  |  |  |  |  |  |
| 50 | 4.2.1 | Finalisation of tender document at SIPO |  | 8w | 2022-08-08 | 2022-09-30 | 46SS-8w, 47, 3FF, 48SS-6w, 10 | 2022-05-26 | 2022-06-29 | 5w |  |  | 0d |  | MJ, MP | 320h | Tue 7.09.21 | 100% | 2018-07-30 | 2018-12-11 | 83 | Marta, Denise, Janez, MP | MP |
| 51 | 4.2.2 | Delivery to ministry |  | 1d | 2022-10-03 | 2022-10-03 | 50 | 2022-06-30 | 2022-06-30 | 1d |  |  | 0d |  | MJ | 8h | Tue 7.09.21 | 100% | 2018-12-11 | 2018-12-11 |  |  | MP |
| 52 | 4.2.3 | Reviewed by ministry |  | 2w | 2022-10-04 | 2022-10-17 | 51 | 2022-07-01 | 2022-07-14 | 2w |  |  | 0d |  | MGRT | 80h | Tue 7.09.21 | 100% | 2018-12-18 | 2018-12-18 |  |  | MP |
| 53 | 4.2.4 | Tender Published |  | 2w | 2022-10-18 | 2022-10-31 | 52 | 2022-07-15 | 2022-07-28 | 2w |  |  | 0d |  | MGRT | 80h | Tue 7.09.21 | 100% | 2018-12-19 | 2019-01-14 | 12 |  | MP |
| 54 | 4.2.5 | Wait for bids |  | 5w | 2022-11-01 | 2022-12-05 | 53 | 2022-07-29 | 2022-09-01 | 5w |  |  | 0d |  | SIPO, MGRT | 200h | Tue 7.09.21 | 100% | 2019-01-15 | 2019-02-18 | 25 |  | MP |
| 55 | 4.2.6 | Opening bids |  | 1w | 2022-12-06 | 2022-12-12 | 54 | 2022-09-02 | 2022-09-08 | 1w |  |  | 0d |  | SIPO, MGRT | 40h | Tue 7.09.21 | 100% | 2019-02-19 | 2019-05-27 | 64 |  | MP |
| 56 | 4.2.7 | Provider to be ready to start (real signing of contract and provider ready to provide resources) |  | 1w | 2022-12-13 | 2022-12-19 | 55 | 2022-09-09 | 2022-09-15 | 1w |  |  | 0d |  | SIPO, MGRT | 40h | Tue 7.09.21 | 100% | 2019-05-27 | 2019-06-28 | 25 |  | MP |
| 57 | 4.3 | M1.1: Tender process concluded | milestone | 0d | 2022-12-19 | 2022-12-19 | 56 | 2022-09-15 | 2022-09-15 | 0d |  |  | 0d |  |  |  | Tue 7.09.21 | 100% | 2019-06-28 | 2019-06-28 |  |  |  |

| ID | WBS | Task | Type | Duration | Start | Finish | Predecessors | Complete | Remaining | Baseline start | Baseline finish | Baseline duration | Baseline 1 start | Baseline 1 finish | Total slack | Free slack | Constraint | Resources | Work | Actual work | Text5 | Text11 |
| --- | --- | --- | --- | --- | --- | --- | --- | --- | --- | --- | --- | --- | --- | --- | --- | --- | --- | --- | --- | --- | --- | --- |
| 58 | 4.4 | **Activation of SIPO External Provider** |  | 10d | 2022-12-20 | 2023-01-02 |  |  |  | 2022-09-16 | 2022-09-29 | 10d | 2021-03-25 | 2021-05-13 | 0d |  |  |  | 80h |  |  |  |
| 59 | 4.4.1 | Handover and training of external providers |  | 2w | 2022-12-20 | 2023-01-02 | 56, 57 |  |  | 2022-09-16 | 2022-09-29 | 2w |  |  | 0d |  |  | SIPO | 80h |  |  |  |
| 60 | 4.5 | M1.2 SIPO External Provider activated | milestone | 0d | 2023-01-02 | 2023-01-02 | 59, 30 |  |  | 2022-09-29 | 2022-09-29 | 0d | 2021-05-13 | 2021-05-13 | 0d |  |  |  |  |  | 09/06/17 | 0% |
| 61 | 5 | **Analysis & Test plan** |  | 180d | 2022-01-27 A | 2022-10-19 |  | 51% | 88.32d | 2022-01-27 | 2022-07-06 | 115d | 2021-02-25 | 2021-04-14 | 53d |  |  |  | 2496h | 1136h |  |  |
| 62 | 5.1 | **Functional Analysis** |  | 167d | 2022-01-27 A | 2022-09-30 |  | 45% | 92.53d | 2022-02-04 | 2022-06-24 | 101d | 2021-02-25 | 2021-03-24 | 66d | 13d |  |  | 1328h | 488h |  |  |
| 63 | 5.1.1 | WF from result of EPO project to form suitable for SISPBO |  | 18w | 2022-03-11 A | 2022-07-28 | 8 | 10% | 16.2w | 2022-03-11 | 2022-04-21 | 6w |  |  | 112d |  | start no earlier than 2022-03-11 |  |  |  |  |  |
| 64 | 5.1.2 | Drafting documentation (sFAD, sIM) |  | 32w | 2022-01-27 | 2022-09-21 | 5 |  |  | 2022-04-11 | 2022-04-29 | 3w |  |  | 7d | 0d |  |  |  |  |  |  |
| 65 | 5.1.3 | **Stage 1** |  | 21d | 2022-02-04 A | 2022-03-04 A |  | 100% |  | 2022-02-04 | 2022-03-04 | 21d |  |  |  |  |  | SIPO | 168h | 168h |  |  |
| 66 | 5.1.3.1 | Functional analysis of features reused from SISPBO |  | 21d | 2022-02-04 A | 2022-03-04 A | 5 | 100% |  | 2022-02-04 | 2022-03-04 | 21d |  |  |  |  |  |  |  |  |  |  |
| 67 | 5.1.4 | **Stage 2** |  | 10d | 2022-03-07 A | 2022-03-18 A | 66 | 100% |  | 2022-03-07 | 2022-03-18 | 10d |  |  |  |  |  | SIPO | 80h | 80h |  |  |
| 68 | 5.1.4.1 | National patents - basic section |  | 1w | 2022-03-07 A | 2022-03-11 A | 66 | 100% |  | 2022-03-07 | 2022-03-11 | 1w |  |  |  |  |  |  |  |  |  |  |
| 69 | 5.1.4.2 | National patents - patent section |  | 1w | 2022-03-14 A | 2022-03-18 A | 68 | 100% |  | 2022-03-14 | 2022-03-18 | 1w |  |  |  |  |  |  |  |  |  |  |
| 70 | 5.1.4.3 | IPC classification |  | 1w | 2022-03-14 A | 2022-03-18 A | 69SS | 100% |  | 2022-03-14 | 2022-03-18 | 1w |  |  |  |  |  |  |  |  |  |  |
| 71 | 5.1.5 | **Stage 3** |  | 15d | 2022-03-21 A | 2022-04-08 A |  | 100% |  | 2022-03-21 | 2022-04-08 | 15d |  |  |  |  |  | SIPO | 120h | 120h |  |  |
| 72 | 5.1.5.1 | EPO basic, IPC, EBD |  | 3d | 2022-03-21 A | 2022-03-23 A | 68, 70 | 100% |  | 2022-03-21 | 2022-03-23 | 3d |  |  |  |  |  |  |  |  |  |  |
| 73 | 5.1.5.2 | SPC - basic and patent integration, publications and patent documents (B, B2, T2, T9) dossiers |  | 7d | 2022-03-24 A | 2022-04-01 A | 69, 72 | 100% |  | 2022-03-24 | 2022-04-01 | 7d |  |  |  |  |  |  |  |  |  |  |
| 74 | 5.1.5.3 | Recordals (common) |  | 1w | 2022-04-04 A | 2022-04-08 A | 73, 66 | 100% |  | 2022-04-04 | 2022-04-08 | 1w |  |  |  |  |  |  |  |  |  |  |
| 75 | 5.1.6 | **Stage 4** |  | 5d | 2022-04-11 A | 2022-04-15 A |  | 100% |  | 2022-04-11 | 2022-04-29 | 15d |  |  |  |  |  |  |  |  |  |  |
| 76 | 5.1.6.1 | Recordals (specific) |  | 1w | 2022-04-11 A | 2022-04-15 A | 66, 71, 74 | 100% |  | 2022-04-11 | 2022-04-15 | 1w |  |  |  |  |  |  |  |  |  |  |
| 77 | 5.1.7 | **Stage 5** |  | 101d | 2022-04-22 A | 2022-09-23 |  | 99% | 0d | 2022-05-16 | 2022-06-10 | 20d |  |  | 0d |  |  | SIPO | 880h | 120h |  |  |
| 78 | 5.1.7.1 | NP WF |  | 3.8w | 2022-04-22 A | 2022-06-01 A | 63FS-6w, 65, 67, 71, 75, 76 | 100% |  |  |  |  |  |  |  |  |  |  |  |  |  |  |
| 79 | 5.1.7.2 | EP WF |  | 3w | 2022-06-02 A | 2022-06-22 A | 63FS-4w, 78 | 100% |  |  |  |  |  |  |  |  |  |  |  |  |  |  |
| 80 | 5.1.7.3 | SPC WF |  | 10.2w | 2022-07-15 A | 2022-09-23 A | 63FS-2w, 65, 67, 71, 75, 79 | 100% |  |  |  |  |  |  |  |  |  |  |  |  |  |  |
| 81 | 5.1.7.4 | Recordals (specific) WF |  | 6.2w | 2022-08-12 A | 2022-09-23 A | 63, 65, 67, 71, 75, 80FS-2w | 100% |  |  |  |  |  |  |  |  |  |  |  |  |  |  |
| 82 | 5.1.7.5 | Common WF |  | 4.2w | 2022-08-26 A | 2022-09-23 A | 63, 81 | 100% |  | 2022-05-16 | 2022-06-10 | 4w |  |  |  |  | start no earlier than 2022-04-19 |  |  |  |  |  |

Notes:
- 67: Functional analysis of new section, features in dossiers and sIM

| ID | WBS | Task | Type | Duration | Start | Finish | Predecessors | Complete | Remaining | Baseline start | Baseline finish | Baseline duration | Baseline 1 start | Baseline 1 finish | Total slack | Free slack | Resources | Work | Actual work | Text5 | Text11 |
| --- | --- | --- | --- | --- | --- | --- | --- | --- | --- | --- | --- | --- | --- | --- | --- | --- | --- | --- | --- | --- | --- |
| 83 | 5.1.8 | **Stage 6** |  | 5d | 2022-09-26 | 2022-09-30 |  |  |  | 2022-06-13 | 2022-06-17 | 5d |  |  | 0d |  | SIPO | 40h |  |  |  |
| 84 | 5.1.8.1 | Review of documentation and analysis results |  | 1w | 2022-09-26 | 2022-09-30 | 82, 64FF-2w |  |  | 2022-06-13 | 2022-06-17 | 1w |  |  | 0d |  |  |  |  |  |  |
| 85 | 5.1.9 | Validate functional documentation |  | 1w | 2022-09-26 | 2022-09-30 | 64, 84SS |  |  | 2022-06-20 | 2022-06-24 | 1w |  |  | 0d |  | SIPO | 40h |  |  |  |
| 86 | 5.2 | M2.1 Functional analysis completed | milestone | 0d | 2022-09-30 | 2022-09-30 | 85, 65, 67, 71, 75, 77, 83 |  |  | 2022-06-24 | 2022-06-24 | 0d |  |  | 0d |  |  |  |  |  |  |
| 87 | 5.3 | **Technical Analysis** |  | 166d | 2022-01-27 A | 2022-09-29 |  | 76% | 40d | 2022-01-27 | 2022-07-06 | 115d |  |  | 1d |  |  | 968h | 648h |  |  |
| 88 | 5.3.1 | Stage 1 |  | 9w | 2022-01-27 A | 2022-03-30 A | 4, 5 | 100% |  | 2022-01-27 | 2022-03-30 | 9w |  |  |  |  |  |  |  |  |  |
| 89 | 5.3.2 | Stage 2 |  | 10.4w | 2022-03-31 A | 2022-06-24 A | 88 | 100% |  | 2022-03-31 | 2022-04-20 | 3w |  |  |  |  | MP, AD, DS | 416h | 416h |  |  |
| 90 | 5.3.3 | Stage 3 |  | 5.8w | 2022-06-27 A | 2022-08-04 A | 89, 71 | 100% |  | 2022-04-21 | 2022-05-11 | 3w |  |  |  |  | MP, AD, DS | 232h | 232h |  |  |
| 91 | 5.3.4 | Stage 4 |  | 7w | 2022-08-05 | 2022-09-22 | 75, 90 |  |  | 2022-05-12 | 2022-06-01 | 3w |  |  | 6d | 0d | MP, AD, DS | 280h |  |  |  |
| 92 | 5.3.5 | Validate technical documentation |  | 1w | 2022-09-23 | 2022-09-29 | 91 |  |  | 2022-06-23 | 2022-07-06 | 2w |  |  | 6d | 0d | SIPO | 40h |  |  |  |
| 93 | 5.4 | M2.2 Technical analysis completed | milestone | 0d | 2022-09-29 | 2022-09-29 | 92 |  |  | 2022-07-06 | 2022-07-06 | 0d |  |  | 6d | 0d |  |  |  |  |  |
| 94 | 5.5 | **Test Plan** |  | 30d | 2022-09-08 | 2022-10-19 |  |  |  | 2022-04-14 | 2022-06-29 | 55d | 2021-03-25 | 2021-04-14 | 53d | 0d |  | 200h |  |  |  |
| 95 | 5.5.1 | Stage 1 |  | 1w | 2022-09-08 | 2022-09-14 | 65, 67, 71, 75, 64FS-2w |  |  | 2022-04-14 | 2022-04-20 | 1w | 2021-03-25 | 2021-04-07 | 58d | 5d | SIPO | 40h |  |  |  |
| 96 | 5.5.2 | Stage 2 |  | 1w | 2022-09-22 | 2022-09-28 | 95, 64 |  |  | 2022-05-05 | 2022-05-11 | 1w | 2021-04-08 | 2021-04-14 | 53d | 0d | SIPO | 40h |  |  |  |
| 97 | 5.5.3 | Stage 3 |  | 1w | 2022-09-29 | 2022-10-05 | 96, 77FS-2w |  |  | 2022-05-26 | 2022-06-01 | 1w | 2021-03-25 | 2021-04-07 | 53d | 0d | SIPO | 40h |  |  |  |
| 98 | 5.5.4 | Stage 4 |  | 1w | 2022-10-06 | 2022-10-12 | 97 |  |  | 2022-06-16 | 2022-06-22 | 1w |  |  | 53d | 0d | SIPO | 40h |  |  |  |
| 99 | 5.5.5 | Validate Business Test Scenarios & Test Cases |  | 1w | 2022-10-13 | 2022-10-19 | 98 |  |  | 2022-06-23 | 2022-06-29 | 1w | 2021-04-08 | 2021-04-14 | 53d | 0d | SIPO | 40h |  |  |  |
| 100 | 5.6 | M2.3 TCs and BTs validated by SIPO | milestone | 0d | 2022-10-19 | 2022-10-19 | 99 |  |  | 2022-06-29 | 2022-06-29 | 0d | 2021-04-14 | 2021-04-14 | 53d | 0d |  |  |  | 09/06/17 | 0% |
| 101 | 5.7 | M2.4 Analysis and test plan completed | milestone | 0d | 2022-10-19 | 2022-10-19 | 62, 87, 94, 92 |  |  | 2022-07-06 | 2022-07-06 | 0d |  |  | 53d | 0d |  |  |  |  |  |
| 102 | 5.8 | D2.1 Functional documentaion (FAD, IM) | milestone | 0d | 2022-09-30 | 2022-09-30 | 86 |  |  | 2022-06-24 | 2022-06-24 | 0d | 2021-04-14 | 2021-04-14 | 0d |  |  |  |  | 09/06/17 | 0% |
| 103 | 5.9 | D2.2 Technical documentation (Integrations, Data migration) | milestone | 0d | 2022-09-29 | 2022-09-29 | 93 |  |  | 2022-07-06 | 2022-07-06 | 0d | 2021-04-14 | 2021-04-14 | 6d |  |  |  |  | 09/06/17 | 0% |
| 104 | 5.10 | D2.3 Test plan (TC, BTS) | milestone | 0d | 2022-10-19 | 2022-10-19 | 100 |  |  | 2022-06-29 | 2022-06-29 | 0d |  |  | 53d |  |  |  |  |  |  |
| 105 | 6 | **Implementation** |  | 409d | 2022-10-20 | 2024-05-08 |  |  |  | 2022-07-07 | 2024-02-12 | 422d | 2021-05-14 | 2021-10-07 | 53d |  |  | 9256h |  |  |  |
| 106 | 6.1 | **Development** |  | 313d | 2022-10-20 | 2023-12-28 |  |  |  | 2022-07-07 | 2023-09-28 | 321d | 2021-05-14 | 2021-08-13 | 0d |  |  | 4160h |  |  |  |
| 107 | 6.1.1 | Implementation including FAT |  | 13mo | 2023-01-03 | 2023-12-28 | 60, 104 |  |  | 2022-09-30 | 2023-09-28 | 13mo | 2021-05-14 | 2021-08-13 | 0d |  | SIPO External Dev, SIPO | 2080h |  |  |  |
| 108 | 6.1.2 | SIPO Integrations |  | 13mo | 2022-10-20 | 2023-10-18 | 101 |  |  | 2022-07-07 | 2023-07-05 | 13mo |  |  | 53d | 0d | SIPO Dev | 2080h |  |  |  |
| 109 | 6.2 | M3.1 Development completed | milestone | 0d | 2023-12-28 | 2023-12-28 | 107 |  |  | 2023-09-28 | 2023-09-28 | 0d | 2021-08-13 | 2021-08-13 | 0d |  |  |  |  | 09/06/17 | 0% |
| 110 | 6.3 | M3.2 Integrations Development completed | milestone | 0d | 2023-10-18 | 2023-10-18 | 108 |  |  | 2023-07-05 | 2023-07-05 | 0d | 2021-08-13 | 2021-08-13 | 53d |  |  |  |  | 09/06/17 | 0% |

Notes:
- 88: Publications and data extraction
- 89: Existing integrations and XML + publications
- 90: SPC publications
- 91: Possible technical issues, integrations
- 95: TC stage 1
- 96: TC stage 2
- 97: BTS
- 98: BTS stage 2

| ID | WBS | Task | Type | Duration | Start | Finish | Predecessors | Baseline start | Baseline finish | Baseline duration | Baseline 1 start | Baseline 1 finish | Total slack | Free slack | Constraint | Resources | Work | Text5 | Text11 | Text25 | Text26 | Text27 | Text4 | Text6 |
| --- | --- | --- | --- | --- | --- | --- | --- | --- | --- | --- | --- | --- | --- | --- | --- | --- | --- | --- | --- | --- | --- | --- | --- | --- |
| 111 | 6.4 | **Data Migration** |  | 313d | 2022-10-20 | 2023-12-28 |  | 2022-07-07 | 2023-09-28 | 321d |  |  | 152d |  |  |  | 4160h |  |  |  |  |  |  |  |
| 112 | 6.4.1 | Data Migration Extraction and Mapping |  | 13mo | 2022-10-20 | 2023-10-18 | 101 | 2022-07-07 | 2023-07-05 | 13mo |  |  | 185d | 33d |  | SIPO Dev | 2080h |  |  |  |  |  |  |  |
| 113 | 6.4.2 | Data Migration Implementation |  | 13mo | 2023-01-03 | 2023-12-28 | 112SS+4w, 60, 12SS+1mo, 13SS+4mo | 2022-09-30 | 2023-09-28 | 13mo |  |  | 152d | 0d |  | SIPO External Dev, SIPO | 2080h |  |  |  |  |  |  |  |
| 114 | 6.5 | M3.2 Data Migration Implementation completed | milestone | 0d | 2023-12-28 | 2023-12-28 | 112, 113 | 2023-09-28 | 2023-09-28 | 0d |  |  | 152d | 0d |  |  |  |  |  |  |  |  |  |  |
| 115 | 6.6 | **Full SAT** |  | 25d | 2023-12-29 | 2024-01-30 |  | 2023-09-29 | 2023-11-02 | 25d | 2021-08-16 | 2021-09-03 | 0d |  |  |  | 328h |  |  |  |  |  |  |  |
| 116 | 6.6.1 | Deployment to SIPO environment |  | 1d | 2023-12-29 | 2023-12-29 | 109, 110 | 2023-09-29 | 2023-09-29 | 1d | 2021-08-16 | 2021-08-16 | 0d |  |  | SIPO Dev | 8h |  |  |  |  |  |  |  |
| 117 | 6.6.2 | Functional testing |  | 4w | 2023-12-30 | 2024-01-24 | 116, 100 | 2023-10-02 | 2023-10-27 | 4w | 2021-08-17 | 2021-08-30 | 0d |  |  | SIPO | 160h |  |  |  |  |  |  |  |
| 118 | 6.6.3 | Performance testing |  | 2w | 2023-12-30 | 2024-01-10 | 116, 100 | 2023-10-02 | 2023-10-13 | 2w | 2021-08-17 | 2021-08-23 | 4d |  |  | SIPO Dev | 80h |  |  |  |  |  |  |  |
| 119 | 6.6.4 | Bug fixing |  | 2w | 2024-01-17 | 2024-01-30 | 117FF+4d, 118 | 2023-10-20 | 2023-11-02 | 2w | 2021-08-30 | 2021-09-03 | 0d |  |  | SIPO Dev, SIPO External Dev | 80h |  |  |  |  |  |  |  |
| 120 | 6.7 | M3.2 SAT completed | milestone | 0d | 2024-01-30 | 2024-01-30 | 119 | 2023-11-02 | 2023-11-02 | 0d | 2021-09-03 | 2021-09-03 | 0d |  |  |  |  | 09/06/17 | 0% |  |  |  |  |  |
| 121 | 6.8 | **UAT** |  | 21d | 2024-01-31 | 2024-02-28 |  | 2023-11-03 | 2023-12-01 | 21d | 2021-09-06 | 2021-09-21 | 0d |  |  |  | 168h |  |  |  |  |  |  |  |
| 122 | 6.8.1 | Deployment to SIPO test environment |  | 1d | 2024-01-31 | 2024-01-31 | 120 | 2023-11-03 | 2023-11-03 | 1d | 2021-09-06 | 2021-09-06 | 0d |  |  | SIPO Dev | 8h |  |  |  |  |  |  |  |
| 123 | 6.8.2 | UAT |  | 4w | 2024-02-01 | 2024-02-28 | 122 | 2023-11-06 | 2023-12-01 | 4w | 2021-09-08 | 2021-09-21 | 0d |  |  | SIPO | 160h |  |  |  |  |  |  |  |
| 124 | 6.9 | M3.3 UAT completed | milestone | 0d | 2024-02-28 | 2024-02-28 | 123, 122 | 2023-12-01 | 2023-12-01 | 0d | 2021-09-21 | 2021-09-21 | 0d |  |  |  |  | 09/06/17 | 0% |  |  |  |  |  |
| 125 | 6.10 | **Launch** |  | 50d | 2024-02-29 | 2024-05-08 |  | 2023-12-04 | 2024-02-12 | 55d |  |  | 0d |  |  |  | 440h | Tue 7.09.21 | 100% | 2020-11-03 | 2020-12-18 | 34 |  |  |
| 126 | 6.10.1 | Deploy in SIPO production env and smoke test |  | 1d | 2024-02-29 | 2024-02-29 | 124, 135 | 2023-12-04 | 2023-12-04 | 1d |  |  | 0d |  |  | SIPO Dev | 8h | Tue 7.09.21 | 100% | 2020-11-03 | 2020-11-09 |  | SIPO DEV, SIPO IT | MP |
| 127 | 6.10.2 | Migration of letters and images |  | 2w | 2024-03-01 | 2024-03-14 | 126, 13 | 2023-12-05 | 2023-12-18 | 2w |  |  | 0d |  |  | SIPO Dev | 80h | Tue 7.09.21 | 0% |  |  |  |  |  |
| 128 | 6.10.3 | Preparation of legacy system in read only mode |  | 1d | 2024-03-13 | 2024-03-13 | 127FS-2d | 2023-12-15 | 2023-12-15 | 1d |  |  | 0d |  |  | SIPO Dev | 8h | Tue 7.09.21 | 100% | 2020-11-03 | 2020-11-09 |  | SIPO IT | MP |
| 129 | 6.10.4 | Legacy system in read-only mode |  | 1d | 2024-03-13 | 2024-03-13 | 128FF | 2023-12-22 | 2023-12-22 | 1d |  |  | 0d |  | start no earlier than 2023-12-22 | SIPO Dev | 8h | Tue 7.09.21 | 100% | 2020-11-20 | 2020-11-20 |  | SIPO IT | MP |
| 130 | 6.10.5 | Data Migration - production |  | 2w | 2024-03-13 | 2024-03-26 | 126SS, 127SS, 129SS, 12 | 2023-12-22 | 2023-12-31 | 2w |  |  | 0d |  |  | SIPO Dev | 80h | Tue 7.09.21 | 100% | 2020-11-10 | 2020-11-16 |  | SIPO DEV, SIPO IT |  |
| 131 | 6.10.6 | Smoke test of migrated data |  | 1d | 2024-03-27 | 2024-03-27 | 130FF+1d | 2024-01-01 | 2024-01-01 | 1d |  |  | 0d |  |  | SIPO Dev | 8h | Tue 7.09.21 | 0% |  |  |  |  |  |
| 132 | 6.10.7 | Full Go Live in case of not used Mngt Reserve |  | 1d | 2024-03-28 | 2024-03-28 | 126, 128, 130, 131 | 2024-01-02 | 2024-01-02 | 1d |  |  | 0d |  | start no earlier than 2024-01-01 | SIPO | 8h | Tue 7.09.21 | 100% | 2020-11-17 | 2020-11-19 |  | SIPO DEV, SIPO IT, EUIPO ECP1 | MP |
| 133 | 6.10.8 | Management Reserve (1/6) |  | 6w | 2024-03-28 | 2024-05-08 | 126, 128, 130, 131 | 2024-01-02 | 2024-02-12 | 6w |  |  | 86d | 0d |  | SIPO | 240h | Tue 7.09.21 | 100% | 2020-11-23 | 2020-12-18 | 20 |  | MP |
| 134 | 6.11 | M3.4 FGL | milestone | 0d | 2024-03-28 | 2024-03-28 | 132 | 2024-01-02 | 2024-01-02 | 0d | 2021-09-23 | 2021-09-23 | 0d |  |  |  |  | 09/06/17 | 0% |  |  |  |  |  |
| 135 | 6.12 | D3.1 Final Package | milestone | 0d | 2024-02-28 | 2024-02-28 | 124 | 2023-12-01 | 2023-12-01 | 0d | 2021-09-03 | 2021-09-03 | 0d |  |  |  |  | 09/06/17 | 0% |  |  |  |  |  |
| 136 | 6.13 | D3.2 Results of testing | milestone | 0d | 2024-02-28 | 2024-02-28 | 124 | 2023-12-01 | 2023-12-01 | 0d | 2021-09-21 | 2021-09-21 | 121d |  |  |  |  | 09/06/17 | 0% |  |  |  |  |  |

Notes:
- 129: MO 20/08 to MP: I propose successor, as we will not consider project implemented until legacy system is in read-only
- 132: MO: Normally it will happen during a weekend, starting with a complete datamigration that normally takes a few days. MP 16.7.2018: To MO JAM, Deadline removed. / MO 20/08 to MP: I propose you remove this task, let's keep the expected FGL after management reserve
- 133: MO 20/08 to MP: if you take ownership of the schedule, I propose you define the management reserve / MP 10/09 current estimation is OK

| ID | WBS | Task | Type | Duration | Start | Finish | Predecessors | Baseline start | Baseline finish | Baseline duration | Baseline 1 start | Baseline 1 finish | Total slack | Free slack | Resources | Work | Text5 | Text11 |
| --- | --- | --- | --- | --- | --- | --- | --- | --- | --- | --- | --- | --- | --- | --- | --- | --- | --- | --- |
| 137 | 7 | **Stabilisation** |  | 100d | 2024-03-29 | 2024-08-15 |  | 2024-01-03 | 2024-05-21 | 100d | 2021-09-24 | 2021-10-25 | 0d |  |  | 640h |  |  |
| 138 | 7.1 | Bug fixing and support |  | 3mo | 2024-05-24 | 2024-08-15 | 134, 141FF+3mo | 2024-02-28 | 2024-05-21 | 3mo | 2021-09-24 | 2021-10-21 | 0d |  |  |  |  |  |
| 139 | 7.2 | **Implementation of remaining modules** |  | 80d | 2024-03-29 | 2024-07-18 |  | 2024-01-03 | 2024-04-23 | 80d |  |  | 0d |  |  |  |  |  |
| 140 | 7.2.1 | Complete publications and INPADOC |  | 1mo | 2024-03-29 | 2024-04-25 | 134 | 2024-01-03 | 2024-01-30 | 1mo |  |  | 55d | 40d |  |  |  |  |
| 141 | 7.2.2 | FO EP designation |  | 2mo | 2024-03-29 | 2024-05-23 | 134, 11 | 2024-01-03 | 2024-02-27 | 2mo |  |  | 0d |  |  |  |  |  |
| 142 | 7.2.3 | EP postgrant procedure |  | 3mo | 2024-03-29 | 2024-06-20 | 134 | 2024-01-03 | 2024-03-26 | 3mo |  |  | 15d | 0d |  |  |  |  |
| 143 | 7.2.4 | Stabliziation of additional modules |  | 4w | 2024-06-21 | 2024-07-18 | 142, 141, 140 | 2024-03-27 | 2024-04-23 | 4w |  |  | 15d | 0d |  |  |  |  |
| 144 | 7.3 | **Update of all documentation** |  | 40d | 2024-05-24 | 2024-07-18 |  | 2024-02-28 | 2024-04-23 | 40d | 2021-09-24 | 2021-10-21 | 15d |  |  | 640h |  |  |
| 145 | 7.3.1 | Functional |  | 2mo | 2024-05-24 | 2024-07-18 | 134, 143FF | 2024-02-28 | 2024-04-23 | 2mo | 2021-09-24 | 2021-10-21 | 15d | 0d | SIPO | 320h |  |  |
| 146 | 7.3.2 | Technical |  | 2mo | 2024-05-24 | 2024-07-18 | 134, 143FF | 2024-02-28 | 2024-04-23 | 2mo | 2021-09-24 | 2021-10-21 | 15d | 0d | SIPO, SIPO Dev, SIPO Ex | 320h |  |  |
| 147 | 7.4 | Handover to SIPO |  | 1w | 2024-07-19 | 2024-07-25 | 146, 145 | 2024-04-24 | 2024-04-30 | 1w | 2021-10-22 | 2021-10-25 | 15d |  |  |  |  |  |
| 148 | 7.5 | M4.1 Stabilisation completed | milestone | 0d | 2024-08-15 | 2024-08-15 | 147, 149, 150, 151, 140, 141, 142 | 2024-05-21 | 2024-05-21 | 0d | 2021-10-25 | 2021-10-25 | 0d |  |  |  | 09/06/17 | 0% |
| 149 | 7.6 | D4.1 Source Code | milestone | 0d | 2024-08-15 | 2024-08-15 | 138, 140, 141, 142 | 2024-05-21 | 2024-05-21 | 0d | 2021-10-21 | 2021-10-21 | 0d |  |  |  | 09/06/17 | 0% |
| 150 | 7.7 | D4.2 Release Notes | milestone | 0d | 2024-07-18 | 2024-07-18 | 146, 140, 141, 142 | 2024-04-23 | 2024-04-23 | 0d | 2021-10-21 | 2021-10-21 | 20d |  |  |  | 09/06/17 | 0% |
| 151 | 7.8 | D4.3 Launch Plan | milestone | 0d | 2024-07-18 | 2024-07-18 | 146, 140, 141, 142 | 2024-04-23 | 2024-04-23 | 0d | 2021-10-21 | 2021-10-21 | 20d |  |  |  | 09/06/17 | 0% |
